# Cronograma V0

Schedule from MS Project, 2025-12-05 to 2025-12-20.

## Calendars

- SENA Sede Gráfica: Mon 09:00-12:00, 13:00-17:00; Tue-Fri 07:00-12:00, 13:00-17:00; Sat 08:00-12:00; Sun off. Exceptions (off unless hours are given): 2025-12-08 (Día de Velitas).

## Schedule

| ID | WBS | Task | Type | Duration | Start | Finish | Predecessors | Total slack |
| --- | --- | --- | --- | --- | --- | --- | --- | --- |
| 1 | 1 | **CTO XXXX MEJORAMIENTO DE CUBIERTAS** |  | 12d | 2025-12-05 | 2025-12-20 |  | 0d |
| 2 | 1.1 | **DOCUMENTACIÓN DE INICIO** |  | 0d | 2025-12-05 | 2025-12-05 |  | 0d |
| 3 | 1.1.1 | Acta de incio | milestone | 0d | 2025-12-05 | 2025-12-05 |  | 0d |
| 4 | 1.1.2 | Cronograma de obra | milestone | 0d | 2025-12-05 | 2025-12-05 | 3 | 0d |
| 5 | 1.1.3 | Información SST de los trabajadores | milestone | 0d | 2025-12-05 | 2025-12-05 | 4 | 0d |
| 6 | 1.2 | **PREPARACIÓN DE LA SUPERFICE** |  | 6d | 2025-12-05 | 2025-12-13 |  | 0d |
| 7 | 1.2.1 | Retiro de impermeabilización existente (manto) |  | 5d | 2025-12-05 | 2025-12-12 | 5 | 0d |
| 8 | 1.2.2 | Protección del área a intervenir |  | 2d | 2025-12-05 | 2025-12-09 | 5SS | 0d |
| 9 | 1.2.3 | Reparación de la superficie |  | 3d | 2025-12-09 | 2025-12-12 | 7SS+2d, 8 | 0d |
| 10 | 1.2.4 | Suministro aplicación y puesta en servicio de Mortero certificado de nivelación |  | 1d | 2025-12-11 | 2025-12-12 | 9SS+2d | 0d |
| 11 | 1.2.5 | Preparación de toda la superficie por medios mecánicos (destroncado con disco diamantado) |  | 1d | 2025-12-12 | 2025-12-13 | 10 | 0d |
| 12 | 1.3 | **SISTEMA DE IMPERMEABILIZACIÓN DE CUBIERTA** |  | 5d | 2025-12-13 | 2025-12-19 |  | 0d |
| 13 | 1.3.1 | Suministro, aplicación y puesta en servicio de membrana de poliurea pura de 2 componentes |  | 2d | 2025-12-13 | 2025-12-16 | 11 | 0d |
| 14 | 1.3.2 | Suministro, aplicación y puesta en servicio de Recubrimiento protector de poliuretano alifático bi-componente flexible |  | 1d | 2025-12-16 | 2025-12-17 | 13 | 0d |
| 15 | 1.3.3 | Suministro, aplicación y puesta en servicio de emboquillado de todos los desagües con sello elastómero base poliuretano |  | 2d | 2025-12-17 | 2025-12-19 | 14 | 1d |
| 16 | 1.4 | **TRATAMIENTO DE POLICARBONATOS** |  | 3d | 2025-12-17 | 2025-12-20 |  | 0d |
| 17 | 1.4.1 | Desmonte de policarbonato, estructura de soporte y elementos de fijación deteriorados en claraboyas |  | 1d | 2025-12-17 | 2025-12-18 | 14SS+1d | 0d |
| 18 | 1.4.2 | Reparación de policarbonato, estructura de soporte y elementos de fijación deteriorados en claraboyas |  | 1d | 2025-12-18 | 2025-12-19 | 17SS+1d | 0d |
| 19 | 1.4.3 | Desmonte, instalación y puesta en funcionamiento del policarbonato existente apoyado sobre la placa |  | 1d | 2025-12-19 | 2025-12-20 | 18 | 0d |
| 20 | 1.4.4 | Prueba de Estanqueidad al Sistema de Impermeabilización Una vez concluidos los trabajos de impermeabilización | milestone | 0d | 2025-12-20 | 2025-12-20 | 19, 15 | 0d |
| 21 | 1.4.5 | Fin de Proyecto | milestone | 0d | 2025-12-20 | 2025-12-20 | 20 | 0d |
